# Cronograma

Schedule from MS Project, 2019-06-10 to 2019-08-09, status date 2019-06-10, costs in S.

## Calendars

- Estándar: Mon-Sun 07:00-12:00, 13:00-16:00.

## Resources

| Resource | Group | Rate | Cost per use |
| --- | --- | --- | --- |
| TOPOGRAFO | Mano de Obra | 12 |  |
| CAPATAZ | Mano de Obra | 28.48 |  |
| OPERARIO | Mano de Obra | 21.91 |  |
| OFICIAL | Mano de Obra | 17.55 |  |
| PEON | Mano de Obra | 15.82 |  |
| CHALECO REFLECTIVO | Material |  | 24.58 |
| ALAMBRE NEGRO RECOCIDO # 16 | Material |  | 4.24 |
| ALAMBRE NEGRO RECOCIDO # 8 | Material |  | 4.25 |
| CLAVOS PARA MADERA CON CABEZA DE 1" | Material |  | 5.08 |
| CLAVOS PARA MADERA CON CABEZA DE 2" | Material |  | 4.66 |
| CLAVOS PARA MADERA CON CABEZA 3" | Material |  | 4.07 |
| PERNO PASANTE FIERRO GALVANIZADO DE 5/8" X 1 1/4" | Material |  | 8.61 |
| PERNO HEXAGONAL DE 3/8" X 7" | Material |  | 4.1 |
| SOPORTE PARA TUBO METALICO (ASEGURADORES) | Material |  | 3.3 |
| CLAVOS CON CABEZA DE 3" | Material |  | 4.24 |
| ANCLAJE DE 3/4"X1.00M | Material |  | 6.54 |
| ACERO CORRUGADO fy=4200 kg/cm2 GRADO 60 | Material |  | 3.2 |
| ARENA FINA | Material |  | 50.8 |
| TIERRA DE CHACRA O VEGETAL | Material |  | 35.17 |
| HUMUS | Material |  | 6 |
| PIEDRA CHANCADA DE 1/2" | Material |  | 76.3 |
| PIEDRA GRANDE DE 4" | Material |  | 38.15 |
| ARENA GRUESA (PUESTO EN OBRA) | Material |  | 58 |
| AFIRMADO | Material |  | 38.14 |
| MATERIALES DE PARTICIPACION COLECTIVA | Material |  | 2500 |
| RESPIRADOR CONTRA EL POLVO | Material |  | 10.17 |
| MEZCLA ASFALTICA | Material |  | 500 |
| CAÑO DE BRONCE 1/2" ESTANDAR | Material |  | 12.71 |
| INTERRUPTOR + TOMACORRIENTE UNIVERSAL BAKELITA | Material |  | 5 |
| ASFALTO RC-250 | Material |  | 18.5 |
| ASFALTO LIQUIDO MC-30 | Material |  | 12.8 |
| CEMENTO PORTLAND TIPO V | Material |  | 23.72 |
| CAL HIDRATADA DE 10 KG | Material |  | 6.78 |
| NEOPREN0 PLANCHA DE 20"x8"x2" | Material |  | 1160 |
| NEOPRENE PLANCHA | Material |  | 125 |
| NEOPRENE PLANCHA DE 4"x10"x1/4" | Material |  | 56.85 |
| OCRE IMPORTADO | Material |  | 5.85 |
| GRASS AMERICANO | Material |  | 8 |
| PLANTA FICUS | Material |  | 70 |
| SOLDADURA CELLOCORD | Material |  | 13.36 |
| CAMILLA PARA EMERGENCIAS | Material |  | 350 |
| BARRENO | Material |  | 5 |
| LACA DESMOLDEADORA | Material |  | 129.87 |
| ALARMA AUDITIVAS | Material |  | 100 |
| PEGAMENTO PARA PVC | Material |  | 140 |
| CAJA DE CONCRERO CONEX. DESAGUE CONCRETO 3 PZAS 70x40x70cm | Material |  | 70 |
| CINTA PLASTICA DE SEÑAL ELECTRICA | Material |  | 0.38 |
| LETREROS DIVERSOS DE SEGURIDAD DE OBRA | Material |  | 72.03 |
| EXTINTOR CONTRA INCENDIOS 9 KG | Material |  | 85 |
| CASCO DE SEGURIDAD | Material |  | 7.62 |
| BOTIQUIN DE EMERGENCIA | Material |  | 85 |
| SOQUETES C/PROTECTOR P/ALUMBR | Material |  | 2.54 |
| CINTA DE SEÑALIZACION DE 350m (PELIGRO OBRAS) | Material |  | 21.16 |
| CINTA TEFLON | Material |  | 1.86 |
| OVEROLES | Material |  | 38.13 |
| PAGO DEL SERVICIO DE AGUA | Material |  | 55 |
| PAGO DEL SERVICIO DE ENERGIA ELECTRICA | Material |  | 250 |
| MOVILIZACION Y DESMOLIVIZACION DE EQUIPO Y HERRAMIENTAS | Material |  | 3000 |
| HORMIGON (PUESTO EN OBRA) | Material |  | 33.9 |
| AGUA | Material |  | 5 |
| ABONO ORGANICO COMPOST | Material |  | 5 |
| OFICINA PARA EL CONTRATISTA | Material |  | 10 |
| S.S.H.H. | Material |  | 10 |
| ALMACEN | Material |  | 10 |
| GUARDIANIA | Material |  | 10 |
| GIGANTOGRAFIA INFORMATIVA DE LA OBRA | Material |  | 300 |
| CERCO LIVIANO | Material |  | 10 |
| MADERA TORNILLO | Material |  | 4.07 |
| WINCHA 30m | Material |  | 21.18 |
| MICROESFERA DE VIDRIO | Material |  | 5.11 |
| ZAPATOS DE SEGURIDAD | Material |  | 29.66 |
| LENTES DE PROTECCION | Material |  | 8.47 |
| FALSO PUENTE DE MADERA | Material |  | 4.56 |
| ESTACA DE MADERA TORNILLO TRATADA | Material |  | 3.4 |
| TRIPLAY DE 6 mm | Material |  | 23.73 |
| PLATINA DE ACERO 3/4" X 8" X 6 m | Material |  | 658 |
| PLATINA DE ACERO 3/4" X 9" X 6 m | Material |  | 750 |
| PLATINA DE ACERO 1/2" X 8" X 6 m | Material |  | 490 |
| PLATINA DE ACERO DE 3/8"X3/8"X6M | Material |  | 13.5 |
| ANGULOS DE ACERO DE 4"X4"X3/8X6M | Material |  | 145 |
| SOLVENTE XILOL | Material |  | 55.08 |
| PINTURA LATEX | Material |  | 18.8 |
| TUBO FIERRO GALVANIZADO ESTANDAR ISO-I 3 1/2" X 3/16" | Material |  | 40 |
| PINTURA PARA TRAFICO AMARILLA | Material |  | 60 |
| PLANCHA DE METAL DE 20 X 20 X 1/4 | Material |  | 830 |
| PALOS DE EUCALIPTO D=3" x 3m | Material |  | 10.17 |
| PALOS DE EUCALIPTO D=2" x 2.40m | Material |  | 7 |
| TUBO PVC SAL 3" PARA DRENAJE | Material |  | 42.39 |
| TUBERIA PVC AGUA C-10 1/2" | Material |  | 2.4 |
| CODO PVC SAP 1/2" | Material |  | 1.69 |
| TEE PVC SAP 1/2" | Material |  | 1.69 |
| CONDUCTORES (PRECIO PROMEDIO) | Material |  | 1.27 |
| UNION PVC 1/2" | Material |  | 1.01 |
| VALVULA COMPUERTA PVC 1/2" | Material |  | 8.47 |
| CAJA DE CONCRERO CON BASE PARA AGUA | Material |  | 65 |
| CALAMINA 2.40 x 0.60mm | Material |  | 26 |
| PLACA RECORDATORIA DE MARMOL ( 0.45 X 0.50 mt ) CON PEDESTAL DE CONCRETO ARMADO incluido IGV . | Material |  | 800 |
| HERRAMIENTAS MANUALES | Equipo | 8 |  |
| MIRAS Y JALONES | Equipo | 3.75 |  |
| MEZCLADORA DE CONCRETO DE 11p3 18 HP | Equipo | 22.5 |  |
| SOLDADORA ELECTRICA MONOFASICA ALTERNA 225 A | Equipo | 7.5 |  |
| MOTOBOMBA 10 HP 4" | Equipo | 127 |  |
| CAMION CISTERNA 4 X 2 (AGUA) 2 000 gl | Equipo | 140 |  |
| CAMION CISTERNA (3 500 GLNS.) | Equipo | 160 |  |
| EQUIPO DE CORTE Y SOLDEO | Equipo | 5.65 |  |
| CIZALLA ELECTRICA PARA CORTE DE FIERRO | Equipo | 5 |  |
| COMPRESORA NEUMATICA 150 HP 380-590 PCM | Equipo | 50 |  |
| COMPACTADOR VIBRATORIO TIPO PLANCHA 7 HP | Equipo | 12 |  |
| RODILLO LISO VIBRATORIO AUTOPROPULSADO 101-135HP 10-12 ton | Equipo | 160 |  |
| RODILLO NEUMATICO AUTOPROPULSADO 135 HP 9-26 ton | Equipo | 160 |  |
| VOLQUETE DE 15m3 | Equipo | 180 |  |
| RETROEXCAVADOR SOBRE LLANTAS 58 HP 1 yd3 | Equipo | 160 |  |
| RETROEXCAVADOR SOBRE ORUGA 115-165 HP 0.75-1.4 Y | Equipo | 180 |  |
| TRACTOR DE ORUGAS DE 190-240 HP | Equipo | 250 |  |
| CARGADOR FRONTAL 125-155 HP3 yd3 | Equipo | 220 |  |
| PAVIMENTADORA SOBRE ORUGAS 69 HP 10-16' | Equipo | 180 |  |
| MARTILLO NEUMATICO DE 21 kg | Equipo | 25 |  |
| VIBRADOR DE CONCRETO 4 HP 1.25" | Equipo | 15 |  |
| MOTONIVELADORA DE 125 HP | Equipo | 190 |  |
| RODILLO LISO VIBRATORIO AUTOPROPULSADO 101-135HP 10- 12 ton | Equipo | 170 |  |
| EQUIPO PARA PINTAR MARCAS EN EL PAVIMENTO | Equipo | 52.44 |  |
| CAMION IMPRIMIDOR 6 X 2 178 - 210 HP 1 800 gal | Equipo | 150 |  |
| TEODOLITO | Equipo | 9 |  |
| SC FLETE TERRESTRE | Subcontrato |  | 2500 |
| ENSAYO DE DENSIDAD DE CAMPO | Subcontrato |  | 70 |
| SC CAPACITACION EN SEGURIDAD Y SALUD | Subcontrato |  | 750 |
| ENSAYO DE COMPACTACION (PROCTOR MODIFICADO) | Subcontrato |  | 140 |
| ROTURA DE CONCRETO | Subcontrato |  | 25 |

## Schedule

| ID | WBS | Task | Duration | Start | Finish | Predecessors | Total slack | Constraint | Resources | Work | Cost | Text1 | Text8 | Text3 | Text4 | Text2 | Text6 |
| --- | --- | --- | --- | --- | --- | --- | --- | --- | --- | --- | --- | --- | --- | --- | --- | --- | --- |
| 1 | 1 | **RECONSTRUCCION AV. PRIMAVERA Y PUENTE DE CERRO AZUL – CP CASA BLANCA, DISTRITO DE CERRO AZUL, PROVINCIA DE CAÑETE-LIMA** | 60d | 2019-06-10 | 2019-08-09 |  | 0d |  |  | 175087h | 648,721.73 |  |  |  |  |  |  |
| 2 | 1.1 | **OBRAS PROVISIONALES ,TRABAJO PRELIMINARES, SEGURIDAD Y SALUD** | 60d | 2019-06-10 | 2019-08-09 |  | 0d |  |  | 90551.7h | 227,816.06 | 01 | 000000000000730 |  |  |  |  |
| 3 | 1.1.1 | **CONSTRUCCIONES PROVISIONALES** | 6d | 2019-06-10 | 2019-06-16 |  | 0d |  |  | 721.18h | 3,268.59 | 01.01 | 000000000000731 |  |  |  |  |
| 4 | 1.1.1.1 | CONSTRUCCION DE ALMACEN , OFICINA Y GUARDIANIA | 1d | 2019-06-10 | 2019-06-11 |  | 0d | start no earlier than 2019-06-10 | CERCO LIVIANO [3000%]; OFICINA PARA EL CONTRATISTA [1200%]; S.S.H.H. [500%]; ALMACEN [3000%]; GUARDIANIA [500%] | 656h | 820 | 01.01.01 | 000000000000732 | 820 | 820 |  |  |
| 5 | 1.1.1.2 | SERVICIOS HIGIENICOS DE OBRA | 5d | 2019-06-11 | 2019-06-16 | 4 | 54d | start no earlier than 2019-06-10 | CAPATAZ [5.8%]; OPERARIO [57.6%]; PEON [57.6%]; ALAMBRE NEGRO RECOCIDO # 16 [8.8%]; TRIPLAY DE 6 mm [963%]; CALAMINA 2.40 x 0.60mm [428%]; PALOS DE EUCALIPTO D=3" x 3m [1043%]; PALOS DE EUCALIPTO D=2" x 2.40m [856%]; CLAVOS CON CABEZA DE 3" [74.9%] | 48.38h | 1,444.27 | 01.01.02 | 000000000000733 | 122.51 | 705.66 | 5.76 | 10 |
| 6 | 1.1.1.3 | CARTEL DE IDENTIFICACION DE LA OBRA DE 3.60 X 2.40 m | 1d | 2019-06-11 | 2019-06-12 | 4 | 0d | start no earlier than 2019-06-10 | CEMENTO PORTLAND TIPO V [66%]; GIGANTOGRAFIA INFORMATIVA DE LA OBRA; CAPATAZ [10%]; OPERARIO; PEON; CLAVOS PARA MADERA CON CABEZA 3" [22%]; HORMIGON (PUESTO EN OBRA) [7.5%]; AGUA [2.2%]; MADERA TORNILLO [8253%]; PERNO HEXAGONAL DE 3/8" X 7" [600%] | 16.8h | 1,004.32 | 01.01.03 | 000000000000849 | 1014.07 | 1014.07 |  |  |
| 7 | 1.1.2 | **INSTALACIONES PROVISIONALES** | 60d | 2019-06-10 | 2019-08-09 |  | 0d |  |  | 7776h | 148,425.99 | 01.02 | 000000000000735 |  |  |  |  |
| 8 | 1.1.2.1 | INSTALACION PROVICIONAL DE AGUA | 60d | 2019-06-10 | 2019-08-09 | 4SS | 0d | start no earlier than 2019-06-10 | PEGAMENTO PARA PVC [2.5%]; CAPATAZ [10%]; OPERARIO [400%]; PEON [400%]; TUBERIA PVC AGUA C-10 1/2" [3000%]; PAGO DEL SERVICIO DE AGUA [200%]; UNION PVC 1/2" [600%]; CAÑO DE BRONCE 1/2" ESTANDAR; CINTA TEFLON [600%]; CODO PVC SAP 1/2" [200%]; TEE PVC SAP 1/2" [200%]; VALVULA COMPUERTA PVC 1/2" [200%] | 3888h | 74,047.77 | 01.02.01 | 000000000000736 | 2822.43 | 2822.43 |  | 0.5 |
| 9 | 1.1.2.2 | INSTALACION PROVICIONAL DE ENERGIA ELECTRICA | 60d | 2019-06-10 | 2019-08-09 | 8SS | 0d | start no earlier than 2019-06-10 | CAPATAZ [10%]; OPERARIO [400%]; PEON [400%]; CINTA PLASTICA DE SEÑAL ELECTRICA [3000%]; CONDUCTORES (PRECIO PROMEDIO) [3000%]; PAGO DEL SERVICIO DE ENERGIA ELECTRICA [200%]; SOQUETES C/PROTECTOR P/ALUMBR [200%]; INTERRUPTOR + TOMACORRIENTE UNIVERSAL BAKELITA [300%] | 3888h | 74,378.22 | 01.02.02 | 000000000000737 | 3152.88 | 3152.88 |  | 0.5 |
| 10 | 1.1.3 | **TRABAJOS PRELIMINARES** | 60d | 2019-06-10 | 2019-08-09 |  | 0d |  |  | 1889.72h | 26,114.72 | 01.03 | 000000000000738 |  |  |  |  |
| 11 | 1.1.3.1 | DESBROCE Y LIMPIEZA DE TERRENO MANUAL | 60d | 2019-06-10 | 2019-08-09 | 6SS-1d | 0d | start no earlier than 2019-06-10 | OFICIAL [97.9%]; PEON [195.8%] | 1409.72h | 23,114.72 | 01.03.01 | 000000000000739 | 5.17 | 12956.9 | 2506.17 | 80 |
| 12 | 1.1.3.2 | MOVILIZACION Y DESMOVILIZACION DE EQUIPO Y HERRAMIENTAS | 60d | 2019-06-10 | 2019-08-09 | 11SS | 0d | start no earlier than 2019-06-10 | MOVILIZACION Y DESMOLIVIZACION DE EQUIPO Y HERRAMIENTAS | 480h | 3,000 | 01.03.02 | 000000000000740 | 3000 | 3000 |  |  |
| 13 | 1.1.4 | **SEGURIDAD Y SALUD** | 60d | 2019-06-10 | 2019-08-09 |  | 0d |  |  | 80164.8h | 50,006.76 | 01.04 | 000000000000741 |  |  |  |  |
| 14 | 1.1.4.1 | ELABORACION, IMPLEMENTACION Y ADMINISTRACION DE PLAN DE SEGURIDAD Y SALUD EN EL TRABAJO | 60d | 2019-06-10 | 2019-08-09 | 12SS | 0d | start no earlier than 2019-06-10 | MATERIALES DE PARTICIPACION COLECTIVA | 480h | 2,500 | 01.04.01 | 000000000000742 | 2500 | 2500 |  |  |
| 15 | 1.1.4.2 | EQUIPOS DE PROTECCION INDIVIDUAL | 60d | 2019-06-10 | 2019-08-09 | 14SS | 0d | start no earlier than 2019-06-10 | ZAPATOS DE SEGURIDAD [2400%]; LENTES DE PROTECCION [2400%]; CHALECO REFLECTIVO [2400%]; RESPIRADOR CONTRA EL POLVO [2400%]; CASCO DE SEGURIDAD [2400%]; OVEROLES [2400%] | 69120h | 2,847.12 | 01.04.02 | 000000000000743 | 118.63 | 2847.12 | 24 |  |
| 16 | 1.1.4.3 | EQUIPOS DE PROTECCION COLECTIVA | 60d | 2019-06-10 | 2019-08-09 | 15SS | 0d | start no earlier than 2019-06-10 | ALARMA AUDITIVAS [400%]; CINTA DE SEÑALIZACION DE 350m (PELIGRO OBRAS) [400%] | 3840h | 484.64 | 01.04.03 | 000000000000744 | 484.64 | 484.64 |  |  |
| 17 | 1.1.4.4 | SEÑALIZACION TEMPORAL DE SEGURIDAD | 60d | 2019-06-10 | 2019-08-09 | 16SS | 0d | start no earlier than 2019-06-10 | LETREROS DIVERSOS DE SEGURIDAD DE OBRA [1000%]; OPERARIO [400%] | 1920h | 42,787.5 | 01.04.04 | 000000000000745 | 1421.42 | 1421.42 |  |  |
| 18 | 1.1.4.5 | CAPACITACION EN SEGURIDAD Y SALUD | 60d | 2019-06-10 | 2019-08-09 | 17SS | 0d | start no earlier than 2019-06-10 | SC CAPACITACION EN SEGURIDAD Y SALUD [1%] | 4.8h | 7.5 | 01.04.05 | 000000000000746 | 750 | 750 |  |  |
| 19 | 1.1.4.6 | RECURSOS PARA RESPUESTAS ANTE EMERGENCIAS EN SEGURIDAD Y SALUD DURANTE EL TRABAJO | 60d | 2019-06-10 | 2019-08-09 | 18SS | 0d | start no earlier than 2019-06-10 | BOTIQUIN DE EMERGENCIA [400%]; CAMILLA PARA EMERGENCIAS [200%]; EXTINTOR CONTRA INCENDIOS 9 KG [400%] | 4800h | 1,380 | 01.04.06 | 000000000000747 | 1380 | 1380 |  |  |
| 20 | 1.2 | **OBRAS DE ARTE Y DRENAJE - PUENTE AV. PRIMAVERA** | 52d | 2019-06-10 | 2019-08-01 |  | 0d |  |  | 81637.9h | 152,272.22 | 02 | 000000000000748 |  |  |  |  |
| 21 | 1.2.1 | TRAZO, NIVELES Y REPLANTEO PRELIMINAR | 1d | 2019-06-10 | 2019-06-11 |  | 0d | start no earlier than 2019-06-10 | CAL HIDRATADA DE 10 KG [352.8%]; PINTURA LATEX [10.6%]; TOPOGRAFO [14.1%]; CAPATAZ [1.4%]; PEON [42.3%]; MIRAS Y JALONES [14.1%]; TEODOLITO [14.1%]; CLAVOS PARA MADERA CON CABEZA DE 2" [141.1%]; ESTACA DE MADERA TORNILLO TRATADA [141.1%]; WINCHA 30m [21.2%] | 6.89h | 126.51 | 02.01 | 000000000000749 | 1.82 | 128.42 | 70.56 | 500 |
| 22 | 1.2.2 | TRAZO, NIVELES Y REPLANTEO DURANTE EL PROCESO | 1d | 2019-06-11 | 2019-06-12 | 21 | 0d | start no earlier than 2019-06-10 | OPERARIO [0.9%]; OFICIAL [5%]; PEON [9.9%]; TEODOLITO [9.9%]; CLAVOS PARA MADERA CON CABEZA DE 1" [44.8%]; OCRE IMPORTADO [74.7%]; MADERA TORNILLO [5978.4%] | 2.06h | 278.35 | 02.02 | 000000000000750 | 1.87 | 279.49 | 149.46 | 1500 |
| 23 | 1.2.3 | **SUB ESTRUCTURA** | 21d | 2019-06-12 | 2019-07-03 |  | 0d |  |  | 1008.79h | 88,965.03 | 02.04 | 000000000000752 |  |  |  |  |
| 24 | 1.2.3.1 | **MOVIMIENTO DE TIERRA** | 6d | 2019-06-12 | 2019-06-18 |  | 0d |  |  | 368.07h | 27,068.29 | 02.04.01 | 000000000000753 |  |  |  |  |
| 25 | 1.2.3.1.1 | EXCAVACION DE ZANJA PARA ZAPATAS | 3d | 2019-06-12 | 2019-06-15 | 22 | 0d | start no earlier than 2019-06-10 | OFICIAL [51.5%]; PEON [102.8%]; RETROEXCAVADOR SOBRE ORUGA 115-165 HP 0.75-1.4 Y [51.5%] | 49.37h | 2,830.82 | 02.04.01.01 | 000000000000754 | 6.16 | 1900.24 | 308.48 | 300 |
| 26 | 1.2.3.1.2 | RELLENO COMPACTADO CON MATERIAL PROPIO | 3d | 2019-06-15 | 2019-06-18 | 25 | 52d | start no earlier than 2019-06-10 | OPERARIO [73.3%]; PEON [293.2%]; COMPACTADOR VIBRATORIO TIPO PLANCHA 7 HP [73.3%]; AGUA [476.5%] | 105.57h | 1,733.86 | 02.04.01.02 | 000000000000755 | 12.53 | 1194.11 | 95.3 | 65 |
| 27 | 1.2.3.1.3 | ELIMINACION DE MATERIAL EXCEDENTE C/EQUIPO D= 10KM | 6d | 2019-06-12 | 2019-06-18 | 25SS | 0d | start no earlier than 2019-06-10 | OPERARIO [73.9%]; PEON [148.1%]; VOLQUETE DE 15m3 [148.1%]; CARGADOR FRONTAL 125-155 HP3 yd3 [73.9%] | 213.13h | 22,503.61 | 02.04.01.03 | 000000000000756 | 28.22 | 7520.07 | 266.48 | 180 |

| ID | WBS | Task | Duration | Start | Finish | Predecessors | Total slack | Free slack | Constraint | Resources | Work | Cost | Text1 | Text8 | Text2 | Text3 | Text4 | Text6 |
| --- | --- | --- | --- | --- | --- | --- | --- | --- | --- | --- | --- | --- | --- | --- | --- | --- | --- | --- |
| 28 | 1.2.3.2 | **ESTRIBOS** | 15d | 2019-06-18 | 2019-07-03 |  | 8d |  |  |  | 640.72h | 61,896.74 | 02.04.02 | 000000000000757 |  |  |  |  |
| 29 | 1.2.3.2.1 | CONCRETO F´C=140 KG/CM2 PARA SOLADO | 1d | 2019-06-18 | 2019-06-19 | 27 | 8d | 0d | start no earlier than 2019-06-10 | CEMENTO PORTLAND TIPO V [2490.4%]; OPERARIO [155.7%]; OFICIAL [77.8%]; PEON [622.6%]; MEZCLADORA DE CONCRETO DE 11p3 18 HP [77.8%]; HORMIGON (PUESTO EN OBRA) [466.9%]; AGUA [2801.7%] | 74.71h | 2,199.24 | 02.04.02.01 | 000000000000758 | 62.26 | 36.27 | 2258.17 | 80 |
| 30 | 1.2.3.2.2 | ENCOFRADO Y DESENCOFRADO PARA ESTRIBOS | 4d | 2019-06-19 | 2019-06-23 | 29 | 8d | 0d | start no earlier than 2019-06-10 | LACA DESMOLDEADORA [966.1%]; OPERARIO [94.7%]; OFICIAL [94.7%]; PEON [189.4%]; ALAMBRE NEGRO RECOCIDO # 16 [9661%]; TRIPLAY DE 6 mm [3284.7%]; MADERA TORNILLO [29755.9%]; CLAVOS CON CABEZA DE 3" [11786.4%] | 121.24h | 6,309.59 | 02.04.02.02 | 000000000000759 | 193.22 | 70.32 | 13587.23 | 12 |
| 31 | 1.2.3.2.3 | CONCRETO F´C=175 KG/CM2 PARA ESTRIBOS | 3d | 2019-06-23 | 2019-06-26 | 30 | 8d | 0d | start no earlier than 2019-06-10 | CEMENTO PORTLAND TIPO V [133274%]; OPERARIO [193.7%]; OFICIAL [193.7%]; PEON [968.6%]; MEZCLADORA DE CONCRETO DE 11p3 18 HP [193.7%]; VIBRADOR DE CONCRETO 4 HP 1.25" [96.9%]; PIEDRA CHANCADA DE 1/2" [11777.7%]; ARENA GRUESA (PUESTO EN OBRA) [8368.4%]; AGUA [3254.4%] | 395.17h | 52,522.12 | 02.04.02.03 | 000000000000760 | 154.97 | 417.94 | 64768.16 | 20 |
| 32 | 1.2.3.2.4 | CURADO DE CONCRETO | 7d | 2019-06-26 | 2019-07-03 | 31 | 8d | 0d | start no earlier than 2019-06-10 | CAPATAZ [8.1%]; PEON [80.5%]; AGUA [483.1%] | 49.59h | 865.79 | 02.04.02.04 | 000000000000803 | 193.22 |  | 386.44 | 80 |
| 33 | 1.2.4 | **SUPER ESTRUCTURA** | 29d | 2019-07-03 | 2019-08-01 |  | 8d |  |  |  | 80620.1h | 62,902.34 | 02.05 | 000000000000761 |  |  |  |  |
| 34 | 1.2.4.1 | **LOSA** | 26d | 2019-07-03 | 2019-07-29 |  | 8d |  |  |  | 80393.7h | 34,124.52 | 02.05.01 | 000000000000762 |  |  |  |  |
| 35 | 1.2.4.1.1 | ENCOFRADO Y DESENCOFRADO PARA LOSA | 5d | 2019-07-11 | 2019-07-16 | 38 | 8d | 0d | start no earlier than 2019-06-10 | LACA DESMOLDEADORA [303.4%]; OPERARIO [94.8%]; OFICIAL [94.8%]; PEON [189.7%]; ALAMBRE NEGRO RECOCIDO # 16 [1213.8%]; TRIPLAY DE 6 mm [728.3%]; MADERA TORNILLO [21787.7%]; CLAVOS CON CABEZA DE 3" [1213.8%] | 151.72h | 4,253.51 | 02.05.01.01 | 000000000000763 | 60.69 | 98.88 | 6001.03 |  |
| 36 | 1.2.4.1.2 | MONTAJE DE FALSO PUENTE | 5d | 2019-07-16 | 2019-07-21 | 35 | 8d | 0d | start no earlier than 2019-06-10 | ALAMBRE NEGRO RECOCIDO # 16 [1000%]; FALSO PUENTE DE MADERA [198445%]; CLAVOS CON CABEZA DE 3" [400%] | 79938h | 9,108.45 | 02.05.01.02 | 000000000000764 |  | 9108.45 | 9108.45 | 60 |
| 37 | 1.2.4.1.3 | CONCRETO F´C=280 KG/CM2 PARA LOSA | 1d | 2019-07-21 | 2019-07-22 | 36 | 8d | 0d | start no earlier than 2019-06-10 | CEMENTO PORTLAND TIPO V [24530%]; OPERARIO [185.8%]; OFICIAL [185.8%]; PEON [495.6%]; MEZCLADORA DE CONCRETO DE 11p3 18 HP [123.9%]; VIBRADOR DE CONCRETO 4 HP 1.25" [61.9%]; PIEDRA CHANCADA DE 1/2" [1784%]; ARENA GRUESA (PUESTO EN OBRA) [892%]; AGUA [1003.5%] | 84.24h | 9,258.38 | 02.05.01.03 | 000000000000765 | 22.3 | 488.38 | 10890.87 | 18 |
| 38 | 1.2.4.1.4 | ACERO DE REFUERZO fy=4,200 kg/cm2 | 8d | 2019-07-03 | 2019-07-11 | 32 | 8d | 0d | start no earlier than 2019-06-10 | OPERARIO [90.1%]; OFICIAL [90.1%]; CIZALLA ELECTRICA PARA CORTE DE FIERRO [90.1%]; ALAMBRE NEGRO RECOCIDO # 16 [13512.9%]; ACERO CORRUGADO fy=4200 kg/cm2 GRADO 60 [236476%] | 172.97h | 10,703.51 | 02.05.01.04 | 000000000000766 | 2252.15 | 5.07 | 11418.4 | 250 |
| 39 | 1.2.4.1.5 | CURADO DE CONCRETO | 7d | 2019-07-22 | 2019-07-29 | 37 | 11d |  | start no earlier than 2019-06-10 | CAPATAZ [7.6%]; PEON [75.9%]; AGUA [151.7%] | 46.73h | 800.66 | 02.05.01.05 | 000000000000804 | 60.69 |  | 121.38 | 80 |
| 40 | 1.2.4.2 | **DRENAJE Y EQUIPAMIENTO** | 10d | 2019-07-22 | 2019-08-01 |  | 8d |  |  |  | 226.48h | 28,777.82 | 02.05.02 | 000000000000767 |  |  |  |  |
| 41 | 1.2.4.2.1 | TUBERIA PVC SAP 3"@ 3M PARA DRENAJE | 2d | 2019-07-22 | 2019-07-24 | 37 | 8d | 0d | start no earlier than 2019-06-10 | OFICIAL [30%]; PEON [30%]; TUBO PVC SAL 3" PARA DRENAJE [1890%] | 9.6h | 961.31 | 02.05.02.01 | 000000000000768 | 18 | 49.09 | 883.62 | 60 |
| 42 | 1.2.4.2.2 | BARANDA METALICA FG° D=2" | 4d | 2019-07-24 | 2019-07-28 | 41 | 8d | 0d | start no earlier than 2019-06-10 | OPERARIO [95%]; OFICIAL [95%]; PEON [95%]; SOLDADORA ELECTRICA MONOFASICA ALTERNA 225 A [95%]; SOLDADURA CELLOCORD [889.2%]; TUBO FIERRO GALVANIZADO ESTANDAR ISO-I 3 1/2" X 3/16" [1140%]; PLATINA DE ACERO 3/4" X 8" X 6 m [14.8%]; PLATINA DE ACERO 3/4" X 9" X 6 m [114%]; PLATINA DE ACERO 1/2" X 8" X 6 m [74.1%]; PERNO PASANTE FIERRO GALVANIZADO DE 5/8" X 1 1/4" [889.2%]; SOPORTE PARA TUBO METALICO (ASEGURADORES) [889.2%] | 121.61h | 3,904.92 | 02.05.02.02 | 000000000000769 | 11.4 | 218.08 | 2486.11 | 12 |
| 43 | 1.2.4.2.3 | APOYOS DE NEOPRENO EXPANDIBLE, COMPRENSIBLE TIPO PANAL 0.05X0.05X5.85M | 2d | 2019-07-28 | 2019-07-30 | 42 | 8d | 0d | start no earlier than 2019-06-10 | OPERARIO [93.8%]; PEON [93.8%]; ANCLAJE DE 3/4"X1.00M [2250%]; NEOPREN0 PLANCHA DE 20"x8"x2" [1500%] | 30h | 18,113.1 | 02.05.02.03 | 000000000000770 | 15 | 1325.26 | 19878.9 |  |
| 44 | 1.2.4.2.4 | JUNTA DE DILATACION, PLATINA DE ACERO DE 3/8"X3/8"X6M, ANGULOS DE ACERO DE 4"X4"X3/8X6M, NEOPRENE PLANCHA | 2d | 2019-07-28 | 2019-07-30 | 43SS | 8d | 0d | start no earlier than 2019-06-10 | OPERARIO [86%]; PEON [86%]; EQUIPO DE CORTE Y SOLDEO [86%]; ACERO CORRUGADO fy=4200 kg/cm2 GRADO 60 [1720%]; SOLDADURA CELLOCORD [1720%]; NEOPRENE PLANCHA [1720%]; PLATINA DE ACERO DE 3/8"X3/8"X6M [275.2%]; ANGULOS DE ACERO DE 4"X4"X3/8X6M [275.2%] | 41.28h | 3,467.93 | 02.05.02.04 | 000000000000771 | 17.2 | 238.14 | 4096.01 |  |
| 45 | 1.2.4.2.5 | TOPES PLANCHA DE METAL DE 20 X 20 X 1/4, INCL NEOPRENE PLANCHA DE 4"x10"x1/4" | 2d | 2019-07-30 | 2019-08-01 | 44 | 8d |  | start no earlier than 2019-06-10 | OPERARIO; OFICIAL [50%]; ACERO CORRUGADO fy=4200 kg/cm2 GRADO 60 [2400%]; PLANCHA DE METAL DE 20 X 20 X 1/4 [48%]; NEOPRENE PLANCHA DE 4"x10"x1/4" [2400%] | 24h | 2,330.56 | 02.05.02.05 | 000000000000772 | 24 | 108.26 | 2598.24 |  |
| 46 | 1.3 | **OBRAS DE ARTE Y DRENAJE - PUENTE AV. PRIMAVERA** | 52d | 2019-06-18 | 2019-08-09 |  | 0d |  |  |  |  |  |  |  |  |  |  |  |
| 47 | 1.3.1 | TRAZO, NIVELES Y REPLANTEO PRELIMINAR | 1d | 2019-06-18 | 2019-06-19 | 27 | 0d |  |  |  |  |  |  |  |  |  |  |  |
| 48 | 1.3.2 | TRAZO, NIVELES Y REPLANTEO DURANTE EL PROCESO | 1d | 2019-06-19 | 2019-06-20 | 47 | 0d |  |  |  |  |  |  |  |  |  |  |  |
| 49 | 1.3.3 | **SUB ESTRUCTURA** | 21d | 2019-06-20 | 2019-07-11 |  | 0d |  |  |  |  |  |  |  |  |  |  |  |
| 50 | 1.3.3.1 | **MOVIMIENTO DE TIERRA** | 6d | 2019-06-20 | 2019-06-26 |  | 0d |  |  |  |  |  |  |  |  |  |  |  |
| 51 | 1.3.3.1.1 | EXCAVACION DE ZANJA PARA ZAPATAS | 3d | 2019-06-20 | 2019-06-23 | 48 | 0d |  |  |  |  |  |  |  |  |  |  |  |
| 52 | 1.3.3.1.2 | RELLENO COMPACTADO CON MATERIAL PROPIO | 3d | 2019-06-23 | 2019-06-26 | 51 | 40d | 0d |  |  |  |  |  |  |  |  |  |  |
| 53 | 1.3.3.1.3 | ELIMINACION DE MATERIAL EXCEDENTE C/EQUIPO D= 10KM | 6d | 2019-06-20 | 2019-06-26 | 51SS | 0d |  |  |  |  |  |  |  |  |  |  |  |

| ID | WBS | Task | Duration | Start | Finish | Predecessors | Total slack | Free slack | Constraint | Resources | Work | Cost | Text1 | Text8 | Text2 | Text3 | Text4 | Text6 |
| --- | --- | --- | --- | --- | --- | --- | --- | --- | --- | --- | --- | --- | --- | --- | --- | --- | --- | --- |
| 54 | 1.3.3.2 | **ESTRIBOS** | 15d | 2019-06-26 | 2019-07-11 |  | 0d |  |  |  |  |  |  |  |  |  |  |  |
| 55 | 1.3.3.2.1 | CONCRETO F´C=140 KG/CM2 PARA SOLADO | 1d | 2019-06-26 | 2019-06-27 | 53 | 0d |  |  |  |  |  |  |  |  |  |  |  |
| 56 | 1.3.3.2.2 | ENCOFRADO Y DESENCOFRADO PARA ESTRIBOS | 4d | 2019-06-27 | 2019-07-01 | 55 | 0d |  |  |  |  |  |  |  |  |  |  |  |
| 57 | 1.3.3.2.3 | CONCRETO F´C=175 KG/CM2 PARA ESTRIBOS | 3d | 2019-07-01 | 2019-07-04 | 56 | 0d |  |  |  |  |  |  |  |  |  |  |  |
| 58 | 1.3.3.2.4 | CURADO DE CONCRETO | 7d | 2019-07-04 | 2019-07-11 | 57 | 0d |  |  |  |  |  |  |  |  |  |  |  |
| 59 | 1.3.4 | **SUPER ESTRUCTURA** | 29d | 2019-07-11 | 2019-08-09 |  | 0d |  |  |  |  |  |  |  |  |  |  |  |
| 60 | 1.3.4.1 | **LOSA** | 26d | 2019-07-11 | 2019-08-06 |  | 0d |  |  |  |  |  |  |  |  |  |  |  |
| 61 | 1.3.4.1.1 | ENCOFRADO Y DESENCOFRADO PARA LOSA | 5d | 2019-07-19 | 2019-07-24 | 64 | 0d |  |  |  |  |  |  |  |  |  |  |  |
| 62 | 1.3.4.1.2 | MONTAJE DE FALSO PUENTE | 5d | 2019-07-24 | 2019-07-29 | 61 | 0d |  |  |  |  |  |  |  |  |  |  |  |
| 63 | 1.3.4.1.3 | CONCRETO F´C=280 KG/CM2 PARA LOSA | 1d | 2019-07-29 | 2019-07-30 | 62 | 0d |  |  |  |  |  |  |  |  |  |  |  |
| 64 | 1.3.4.1.4 | ACERO DE REFUERZO fy=4,200 kg/cm2 | 8d | 2019-07-11 | 2019-07-19 | 58 | 0d |  |  |  |  |  |  |  |  |  |  |  |
| 65 | 1.3.4.1.5 | CURADO DE CONCRETO | 7d | 2019-07-30 | 2019-08-06 | 63 | 3d |  |  |  |  |  |  |  |  |  |  |  |
| 66 | 1.3.4.2 | **DRENAJE Y EQUIPAMIENTO** | 10d | 2019-07-30 | 2019-08-09 |  | 0d |  |  |  |  |  |  |  |  |  |  |  |
| 67 | 1.3.4.2.1 | TUBERIA PVC SAP 3"@ 3M PARA DRENAJE | 2d | 2019-07-30 | 2019-08-01 | 63 | 0d |  |  |  |  |  |  |  |  |  |  |  |
| 68 | 1.3.4.2.2 | BARANDA METALICA FG° D=2" | 4d | 2019-08-01 | 2019-08-05 | 67 | 0d |  |  |  |  |  |  |  |  |  |  |  |
| 69 | 1.3.4.2.3 | APOYOS DE NEOPRENO EXPANDIBLE, COMPRENSIBLE TIPO PANAL 0.05X0.05X5.85M | 2d | 2019-08-05 | 2019-08-07 | 68 | 0d |  |  |  |  |  |  |  |  |  |  |  |
| 70 | 1.3.4.2.4 | JUNTA DE DILATACION, PLATINA DE ACERO DE 3/8"X3/8"X6M, ANGULOS DE ACERO DE 4"X4"X3/8X6M, NEOPRENE PLANCHA | 2d | 2019-08-05 | 2019-08-07 | 69SS | 0d |  |  |  |  |  |  |  |  |  |  |  |
| 71 | 1.3.4.2.5 | TOPES PLANCHA DE METAL DE 20 X 20 X 1/4, INCL NEOPRENE PLANCHA DE 4"x10"x1/4" | 2d | 2019-08-07 | 2019-08-09 | 70 | 0d |  |  |  |  |  |  |  |  |  |  |  |
| 72 | 1.4 | **MITIGACION AMBIENTAL** | 25d | 2019-06-23 | 2019-07-18 |  | 22d |  |  |  | 2704.8h | 266,380.81 | 05 | 000000000000781 |  |  |  |  |
| 73 | 1.4.1 | RIEGO DE AGUA CON CAMION CISTERNA | 25d | 2019-06-23 | 2019-07-18 | 51 | 22d | 0d | start no earlier than 2019-06-10 | PEON [415.8%]; MOTOBOMBA 10 HP 4" [415.8%]; CAMION CISTERNA (3 500 GLNS.) [415.8%] | 2494.8h | 251,825.11 | 05.01 | 000000000000782 | 1039.5 | 19.41 | 20176.7 | 1000 |
| 74 | 1.4.2 | ACONDICIMIENTO DE BOTADERO | 15d | 2019-06-23 | 2019-07-08 | 73SS | 32d |  | start no earlier than 2019-06-10 | OPERARIO [25%]; PEON; VOLQUETE DE 15m3 [25%]; CARGADOR FRONTAL 125-155 HP3 yd3 [25%] | 210h | 14,555.7 | 05.02 | 000000000000783 | 100 | 9.76 | 976 | 400 |
| 75 | 1.5 | **VARIOS** | 60d | 2019-06-10 | 2019-08-09 |  | 0d |  |  |  | 192.53h | 2,252.63 | 06 | 000000000000784 |  |  |  |  |
| 76 | 1.5.1 | ROTURA DEL CONCRETO | 1d | 2019-07-30 | 2019-07-31 | 57, 63, 31, 37 | 9d |  | start no earlier than 2019-06-10 | ROTURA DE CONCRETO [200%] | 16h | 50 | 06.01 | 000000000000785 |  | 25 | 50 | 25 |
| 77 | 1.5.2 | ENSAYO DE COMPACTACION DE SUELOS | 2d | 2019-06-26 | 2019-06-28 | 52, 26 | 40d | 0d | start no earlier than 2019-06-10 | ENSAYO DE COMPACTACION (PROCTOR MODIFICADO) [400%] | 64h | 560 | 06.02 | 000000000000786 |  | 140 | 560 |  |
| 78 | 1.5.3 | ENSAYO DE DENSIDAD DE CAMPO | 2d | 2019-06-28 | 2019-06-30 | 77, 52, 26 | 40d |  | start no earlier than 2019-06-10 | ENSAYO DE DENSIDAD DE CAMPO [500%] | 80h | 350 | 06.03 | 000000000000836 |  | 70 | 350 | 24 |
| 79 | 1.5.4 | SUMINISTRO E INSTALACION DE PLACA RECORDATORIA DE MARMOL ( 045 X 0.50 mt ) INCLUIDO PEDESTAR DE CONCRETO ARMADO | 1d | 2019-08-07 | 2019-08-08 | 71SS | 1d | 0d | start no earlier than 2019-06-10 | OPERARIO [50%]; PEON; PLACA RECORDATORIA DE MARMOL ( 0.45 X 0.50 mt ) CON PEDESTAL DE CONCRETO ARMADO incluido IGV . | 12h | 1,014.2 | 06.04 | 000000000000787 |  | 1014.2 | 1014.2 |  |
| 80 | 1.5.5 | LIMPIEZA FINAL DE OBRA | 1d | 2019-08-07 | 2019-08-08 | 79SS | 1d |  | start no earlier than 2019-06-10 | OPERARIO [9.4%]; PEON [187.3%] | 15.73h | 253.43 | 06.05 | 000000000000788 | 1310.95 | 2.85 | 3736.21 | 100 |
| 81 | 1.5.6 | FLETE TERRESTRE | 60d | 2019-06-10 | 2019-08-09 | 8SS | 0d |  | start no earlier than 2019-06-10 | SC FLETE TERRESTRE [1%] | 4.8h | 25 | 06.06 | 000000000000789 |  | 2500 | 2500 |  |
